# Procurement Schedule

Schedule from MS Project, 2014-10-20 to 2015-12-23.

## Calendars

- Standard: Mon-Fri 08:00-12:00, 13:00-17:00; Sat-Sun off.

## Schedule

| ID | WBS | Task | Type | Duration | Start | Finish | Predecessors | Total slack | Free slack | Constraint |
| --- | --- | --- | --- | --- | --- | --- | --- | --- | --- | --- |
| 2 | 1 | **Executive Committee** |  | 205d | 2015-01-01 | 2015-10-15 |  | 4d |  |  |
| 3 | 1.1 | Approve Project Goals | milestone | 0d | 2015-01-01 | 2015-01-01 |  | 255d |  | start no earlier than 2015-01-01 |
| 4 | 1.2 | Approve Request for LOIs | milestone | 0d | 2015-01-01 | 2015-01-01 |  | 4d | 0d | start no earlier than 2015-01-01 |
| 5 | 1.3 | Approve Basic Configuration | milestone | 0d | 2015-02-20 | 2015-02-20 |  | 219d |  | start no earlier than 2015-02-20 |
| 6 | 1.4 | Approve Release of RFQ | milestone | 0d | 2015-02-20 | 2015-02-20 |  | 7d | 3d | start no earlier than 2015-02-20 |
| 7 | 1.5 | Approve Design-Builder Shortlist | milestone | 0d | 2015-05-07 | 2015-05-07 |  | 0d |  | start no earlier than 2015-05-07 |
| 8 | 1.6 | Approve Best Value ITP Format | milestone | 0d | 2015-05-07 | 2015-05-07 |  | 119d | 1d | finish no earlier than 2015-05-07 |
| 9 | 1.7 | Approve Release of Final RFP | milestone | 0d | 2015-06-25 | 2015-06-25 |  | 90d | 5d | start no earlier than 2015-06-25 |
| 10 | 1.8 | Approve Selection of Design-Builder | milestone | 0d | 2015-10-15 | 2015-10-15 |  | 5d |  | start no earlier than 2015-10-15 |
| 12 | 2 | **Procurement Process** |  | 255d | 2015-01-01 | 2015-12-23 |  | 0d |  |  |
| 13 | 2.1 | Request Letters of Interest (LOIs) | milestone | 0d | 2015-01-01 | 2015-01-01 | 4 | 4d | 0d |  |
| 14 | 2.2 | Industry Review (Open Process) |  | 70d | 2015-01-07 | 2015-04-14 | 18FF, 13 | 181d |  |  |
| 15 | 2.3 | LOIs due | milestone | 0d | 2015-04-09 | 2015-04-09 | 13FF+35d | 185d |  | start no earlier than 2015-04-09 |
| 16 | 2.4 | Prepare Request for Qualifications (RFQs) |  | 39d | 2015-01-01 | 2015-02-24 | 13 | 4d | 0d |  |
| 17 | 2.5 | Issue RFQ | milestone | 0d | 2015-02-24 | 2015-02-24 | 16, 6 | 4d | 0d | start no earlier than 2015-01-21 |
| 18 | 2.6 | Proposer Prepare SOQs |  | 35d | 2015-02-25 | 2015-04-14 | 17 | 4d | 0d |  |
| 19 | 2.7 | Receive SOQs | milestone | 0d | 2015-04-14 | 2015-04-14 | 18 | 4d | 0d |  |
| 20 | 2.8 | Review SOQs |  | 12d | 2015-04-15 | 2015-04-30 | 19 | 4d |  |  |
| 21 | 2.9 | Announce Shortlisted Contractors | milestone | 0d | 2015-05-07 | 2015-05-07 | 20, 7 | 0d |  |  |
| 22 | 2.10 | Issue Draft RFP | milestone, manual | 0d | 2015-05-14 | 2015-05-14 | 54, 21FS+5d |  |  | start no earlier than 2015-05-14 |
| 23 | 2.11 | Industry Review (shortlisted Contractors) |  | 20d | 2015-05-14 | 2015-06-10 | 22 | 0d |  |  |
| 24 | 2.12 | Compile Final RFP |  | 15d | 2015-06-11 | 2015-07-01 | 23 | 0d |  |  |
| 25 | 2.13 | Issue Final RFP | milestone | 0d | 2015-07-01 | 2015-07-01 | 24, 9, 53 | 85d | 0d |  |
| 26 | 2.14 | 1 on 1 Meetings & ATC Process |  | 30d | 2015-07-16 | 2015-08-26 | 25FS+10d | 85d |  |  |
| 27 | 2.15 | Proposers Prepare Proposals |  | 60d | 2015-07-02 | 2015-09-23 | 24 | 0d |  |  |
| 28 | 2.16 | Receive Proposals | milestone | 0d | 2015-09-23 | 2015-09-23 | 27 | 0d |  |  |
| 29 | 2.17 | Evaluate Proposals |  | 20d | 2015-09-24 | 2015-10-21 | 28 | 0d |  |  |
| 30 | 2.18 | Award Project | milestone | 0d | 2015-10-21 | 2015-10-21 | 29, 10 | 0d |  |  |
| 31 | 2.19 | Contract Execution |  | 45d | 2015-10-22 | 2015-12-23 | 30 | 0d |  |  |
| 32 | 2.20 | Notice-to-Proceed | milestone | 0d | 2015-12-23 | 2015-12-23 | 31 | 0d |  |  |

| ID | WBS | Task | Type | Duration | Start | Finish | Predecessors | Total slack | Free slack | Constraint |
| --- | --- | --- | --- | --- | --- | --- | --- | --- | --- | --- |
| 34 | 3 | **Design Development** |  | 174d | 2014-10-20 | 2015-06-18 |  | 134d |  |  |
| 35 | 3.1 | Develop Basic Configuration |  | 115d | 2014-10-20 | 2015-03-27 |  | 193d |  |  |
| 36 | 3.2 | Supplementary Field Investigations |  | 60d | 2015-01-02 | 2015-03-26 |  | 194d |  | start no earlier than 2015-01-02 |
| 37 | 3.3 | Risk Assessment |  | 60d | 2015-01-08 | 2015-04-01 |  | 190d |  | start no earlier than 2015-01-08 |
| 38 | 3.4 | Design Refinement (for risk allocation) |  | 90d | 2015-01-08 | 2015-05-13 |  | 160d |  | start no earlier than 2015-01-08 |
| 39 | 3.5 | Design Refinement (for AREs) |  | 70d | 2015-02-26 | 2015-06-03 | 23SF+15d | 145d |  |  |
| 40 | 3.6 | Utilities Coordination and Agreements |  | 130d | 2014-12-19 | 2015-06-18 |  | 134d |  | start no earlier than 2014-12-19 |
| 42 | 4 | **RFP Development** |  | 105d | 2015-02-20 | 2015-07-16 |  | 114d |  |  |
| 43 | 4.1 | Prepare Book 1 - Contract |  | 40d | 2015-02-20 | 2015-04-16 |  | 179d |  | start no earlier than 2015-02-20 |
| 44 | 4.2 | Prepare Draft Instructions to Bidders (ITP) |  | 55d | 2015-02-23 | 2015-05-08 | 8FF | 118d | 4d | start no earlier than 2015-02-22 |
| 45 | 4.3 | Develop Draft Book 2 - Technical Requirements |  | 55d | 2015-02-27 | 2015-05-14 |  | 114d | 0d | finish no earlier than 2015-05-14 |
| 46 | 4.4 | Develop Book 4 - Contract Drawings |  | 55d | 2015-02-27 | 2015-05-14 |  | 114d | 0d | finish no earlier than 2015-05-14 |
| 47 | 4.5 | Assemble Book 5 - Reference Documents |  | 55d | 2015-02-27 | 2015-05-14 |  | 159d |  | finish no earlier than 2015-05-14 |
| 48 | 4.6 | Compile Draft RFP |  | 15d | 2015-05-15 | 2015-06-04 | 44, 45, 46 | 114d | 0d |  |
| 49 | 4.7 | Prepare Final RFP |  | 30d | 2015-06-05 | 2015-07-16 | 48, 23FF | 114d |  |  |
| 51 | 5 | **Clearances** |  | 183d | 2014-10-20 | 2015-07-02 |  | 3d |  |  |
| 52 | 5.1 | Environmental Clearence |  | 180d | 2014-10-20 | 2015-06-26 |  | 88d | 0d |  |
| 53 | 5.2 | EA FONSI, EOS ROD, CE, etc | milestone | 0d | 2015-06-26 | 2015-06-26 | 52 | 88d | 3d |  |
| 54 | 5.3 | Interstate Access Request |  | 145d | 2014-10-20 | 2015-05-08 |  | 3d |  |  |
| 55 | 5.4 | Local Agency Funding Commitments |  | 120d | 2014-10-20 | 2015-04-03 |  | 188d |  | start no earlier than 2014-10-20 |
| 56 | 5.5 | Intergovernmental Aggreements (IGAs) |  | 90d | 2015-02-20 | 2015-06-25 |  | 129d |  | start no earlier than 2015-02-20 |
| 57 | 5.6 | CDOT 128 Clearance | milestone | 0d | 2015-07-02 | 2015-07-02 |  | 125d |  | start no earlier than 2015-07-02 |
| 58 | 6 | Right of Way Acquisition |  | 300d | 2014-10-20 | 2015-12-11 |  | 8d |  |  |
